# 2010 Support Pack Implementation Project

Schedule from MS Project, 2010-08-23 to 2011-02-01, A marks actual dates.

## Calendars

- Standard: Mon-Fri 08:00-12:00, 13:00-17:00; Sat-Sun off.
- 24 Hours: Mon-Sun 00:00-24:00.

## Resources

| Resource |
| --- |
| ERP Manager |
| PM |
| Team Lead |
| Testing Coordinator |
| R3 |
| TC |
| Transport Coordinator |
| Testing Coordinator - HR |
| Testing Coordinator - FI |
| TranC |
| TransC |
| TestC - HR |
| TestC - FI |
| TestC-HR |
| TestC-FI |
| Team Lead-HR |
| Team Lead-FI |
| IDD |
| QA |
| ABAP Lead |
| BA1 |
| DW |
| R3-1 |
| R3-2 |
| R3-3 |
| ABAP |
| FIN |
| log |
| EHS |
| HRP |
| Bus |
| SAP |
| Core |
| All |
| BC |
| IST-SAP |
| R3-4 |
| QA-4 |
| Bus-Val |
| FIN-1 |
| LOG-1 |
| EHS-1 |
| FIN-Team |
| Log-Team |
| EHS-Team |
| HRP-Team |
| OIS |
| OPS |
| SO |

## Schedule

| ID | WBS | Task | Duration | Start | Finish | Predecessors | Complete | Resources | Work | Actual work |
| --- | --- | --- | --- | --- | --- | --- | --- | --- | --- | --- |
| 1 | 1 | **Project Preparation & Planning** | 77d | 2010-08-23 08:00 A | 2010-12-07 17:00 A |  | 100% |  | 297h | 297h |
| 2 | 1.1 | **Appoint project team, define roles and responsibilities** | 9.12d | 2010-08-23 08:00 A | 2010-09-03 09:00 A |  | 100% |  | 73h | 73h |
| 3 | 1.1.1 | Appoint project manager | 1h | 2010-08-23 08:00 A | 2010-08-23 09:00 A |  | 100% | ERP Manager | 1h | 1h |
| 4 | 1.1.2 | Define project team, member roles and responsibilities | 1d | 2010-08-24 09:00 A | 2010-08-25 09:00 A | 3FS+1d | 100% | PM | 8h | 8h |
| 5 | 1.1.3 | Appoint project team members (core team/testing coordinators/extended team, etc …) | 3d | 2010-08-25 09:00 A | 2010-08-30 09:00 A | 4 | 100% | PM | 24h | 24h |
| 6 | 1.1.4 | Notify project team members of their role | 1d | 2010-08-31 09:00 A | 2010-09-01 09:00 A | 5FS+1d | 100% | PM; Team Lead-HR; Team Lead-FI | 24h | 24h |
| 7 | 1.1.5 | Update business owner list with new / changed owners | 1d | 2010-09-02 09:00 A | 2010-09-03 09:00 A | 6FS+1d | 100% | TestC-FI; TestC-HR | 16h | 16h |
| 8 | 1.2 | **Develop Project Plan** | 19.21d | 2010-08-23 09:00 A | 2010-09-17 10:40 A | 3 | 100% |  | 112h | 112h |
| 9 | 1.2.1 | Determine support package availability date | 1d | 2010-08-23 09:00 A | 2010-08-24 09:00 A |  | 100% | PM | 8h | 8h |
| 10 | 1.2.2 | Determine desired support package & enhancement package levels | 1d | 2010-08-24 09:00 A | 2010-08-25 09:00 A | 9 | 100% | PM | 8h | 8h |
| 11 | 1.2.3 | Determine dates for production freeze | 1d | 2010-09-01 10:40 A | 2010-09-02 10:40 A | 15 | 100% | PM | 8h | 8h |
| 12 | 1.2.4 | Define high level plan, milestones, deliverables | 5d | 2010-09-02 10:40 A | 2010-09-09 10:40 A | 11 | 100% | PM | 40h | 40h |
| 13 | 1.2.5 | Identify Pending Projects that may collide with the project | 1d | 2010-09-09 10:40 A | 2010-09-10 10:40 A | 12 | 100% | PM | 8h | 8h |
| 14 | 1.2.6 | Review any development/cleanup work that can be included in the project | 5d | 2010-09-10 10:40 A | 2010-09-17 10:40 A | 13 | 100% | BC | 40h | 40h |
| 15 | 1.3 | **Define environments, refresh schedule, support pack plan** | 2.21d | 2010-08-30 09:00 A | 2010-09-01 10:40 A |  | 100% |  | 9h | 9h |
| 16 | 1.3.1 | Identify environments for Staging, and TST (DEV not refreshed) | 1h | 2010-08-30 09:00 A | 2010-08-30 10:00 A | 5 | 100% | R3; PM | 2h | 2h |
| 17 | 1.3.2 | Develop/update env landscape document | 1h | 2010-08-30 10:00 A | 2010-08-30 11:00 A | 16 | 100% | PM | 1h | 1h |
| 18 | 1.3.3 | Determine production snapshot dates for STG, TST | 1h | 2010-09-01 09:00 A | 2010-09-01 10:00 A | 6 | 100% | TestC-FI; TestC-HR | 2h | 2h |
| 19 | 1.3.4 | Determine dates for STG, TST refreshes | 1h | 2010-09-01 09:00 A | 2010-09-01 10:00 A | 6 | 100% | R3; PM | 2h | 2h |
| 20 | 1.3.5 | Plan datawarehouse extracts | 0.67h | 2010-09-01 10:00 A | 2010-09-01 10:40 A | 19 | 100% | R3; PM; DW | 2h | 2h |
| 21 | 1.4 | **Develop cut-over plan** | 24d | 2010-11-04 08:00 A | 2010-12-07 17:00 A | 199 | 100% |  | 103h | 103h |
| 22 | 1.4.1 | Identify resources | 1d | 2010-11-04 08:00 A | 2010-11-04 17:00 A |  | 100% | PM | 8h | 8h |
| 23 | 1.4.2 | Prep cut-over plan document | 4h | 2010-11-04 08:00 A | 2010-11-04 12:00 A |  | 100% | PM | 4h | 4h |
| 24 | 1.4.3 | Review transports resulting from SPAU | 4h | 2010-11-04 08:00 A | 2010-11-04 12:00 A |  | 100% | Core | 4h | 4h |
| 25 | 1.4.4 | Review transports resulting from Unit Test | 4h | 2010-11-11 08:00 A | 2010-11-11 12:00 A | 218 | 100% | Core | 4h | 4h |
| 26 | 1.4.5 | Review transports resulting from SIT/UAT | 4h | 2010-12-07 08:00 A | 2010-12-07 12:00 A | 261 | 100% | Core | 4h | 4h |
| 27 | 1.4.6 | Schedule cut-over plan meeting | 1h | 2010-11-11 13:00 A | 2010-11-11 14:00 A | 25 | 100% | PM | 1h | 1h |
| 28 | 1.4.7 | Cut-over plan meeting | 2h | 2010-11-11 14:00 A | 2010-11-11 16:00 A | 27 | 100% | Core | 2h | 2h |
| 29 | 1.4.8 | Develop cut-over plan & publish | 9d | 2010-11-11 16:00 A | 2010-11-24 16:00 A | 28 | 100% | PM | 72h | 72h |
| 30 | 1.4.9 | Finalize cut-over plan & publish | 4h | 2010-12-07 13:00 A | 2010-12-07 17:00 A | 26 | 100% | Core | 4h | 4h |

| ID | WBS | Task | Duration | Start | Finish | Predecessors | Complete | Constraint | Resources | Work | Actual work |
| --- | --- | --- | --- | --- | --- | --- | --- | --- | --- | --- | --- |
| 31 | 2 | **Communication** | 112.25d | 2010-08-23 08:00 A | 2011-01-26 10:00 A |  | 100% |  |  | 262h | 262h |
| 32 | 2.1 | Develop project wiki | 5d | 2010-08-25 09:00 A | 2010-09-01 09:00 A | 3FS+2d | 100% |  | PM; IDD; QA | 120h | 120h |
| 33 | 2.2 | Schedule IS&T (Admin Systems) project kick-off meeting | 2h | 2010-08-23 08:00 A | 2010-08-23 10:00 A |  | 100% |  | PM; ERP Manager | 4h | 4h |
| 34 | 2.3 | Schedule SAPbiz project kick-off meeting (last meeting of September) | 1h | 2010-08-25 09:00 A | 2010-08-25 10:00 A | 3FS+2d | 100% |  | PM | 1h | 1h |
| 35 | 2.4 | Schedule Steering Committee Meeting | 1d | 2010-08-27 09:00 A | 2010-08-30 09:00 A | 3FS+4d | 100% |  | PM | 8h | 8h |
| 36 | 2.5 | Schedule Core Team Meeting(s) | 1d | 2010-09-02 09:00 A | 2010-09-03 09:00 A | 6FS+1d | 100% |  | PM | 8h | 8h |
| 37 | 2.6 | Review/update communication email list sa-upgrade-core@mit.edu | 1h | 2010-09-03 09:00 A | 2010-09-03 10:00 A | 7 | 100% |  | PM | 1h | 1h |
| 38 | 2.7 | Review/update communication email list ist-sap@mit.edu | 1h | 2010-09-03 10:00 A | 2010-09-03 11:00 A | 37 | 100% |  | PM | 1h | 1h |
| 39 | 2.8 | Prepare Project Presentation for the Steering Committee | 2d | 2010-08-30 09:00 A | 2010-09-01 09:00 A | 35 | 100% |  | PM | 16h | 16h |
| 40 | 2.9 | Prepare Project Presentation for IS&T | 2d | 2010-09-03 13:00 A | 2010-09-07 12:00 A | 39 | 100% |  | PM; QA; R3 | 48h | 48h |
| 41 | 2.10 | Prepare Project Presentation for SAPbiz | 2d | 2010-09-07 13:00 A | 2010-09-09 12:00 A | 40 | 100% |  | PM; QA; R3 | 48h | 48h |
| 42 | 2.11 | IS&T Kick off meeting | 2h | 2010-09-09 10:40 A | 2010-09-09 13:40 A | 12 | 100% |  | IST-SAP | 2h | 2h |
| 43 | 2.12 | Review/update communication email list sap-vailidation-team@mit.edu | 1h | 2010-12-02 08:00 A | 2010-12-02 09:00 A | 253SS+15d | 100% |  | PM; TestC - HR; TestC - FI | 3h | 3h |
| 44 | 2.13 | **Steering Committee Meeting** | 85.12d | 2010-09-06 08:00 A | 2011-01-03 09:00 A |  | 100% |  |  |  |  |
| 45 | 2.13.1 | Steering Committee Meeting 1 | 1h | 2010-09-06 08:00 A | 2010-09-06 09:00 A |  | 100% | start no earlier than 2010-09-06 08:00 |  |  |  |
| 46 | 2.13.2 | Steering Committee Meeting 2 | 1h | 2010-10-04 08:00 A | 2010-10-04 09:00 A |  | 100% | start no earlier than 2010-10-04 08:00 |  |  |  |
| 47 | 2.13.3 | Steering Committee Meeting 3 | 1h | 2010-11-01 08:00 A | 2010-11-01 09:00 A |  | 100% | start no earlier than 2010-11-01 08:00 |  |  |  |
| 48 | 2.13.4 | Steering Committee Meeting 4 | 1h | 2010-12-06 08:00 A | 2010-12-06 09:00 A |  | 100% | start no earlier than 2010-12-06 08:00 |  |  |  |
| 49 | 2.13.5 | Steering Committee Meeting 5 | 1h | 2011-01-03 08:00 A | 2011-01-03 09:00 A |  | 100% | start no earlier than 2011-01-03 08:00 |  |  |  |
| 50 | 2.14 | **Core Team Meeting** | 70.12d | 2010-09-13 08:00 A | 2010-12-20 09:00 A |  | 100% |  |  |  |  |
| 51 | 2.14.1 | Core Team Meeting 1 | 1h | 2010-09-13 08:00 A | 2010-09-13 09:00 A |  | 100% | start no earlier than 2010-09-13 08:00 |  |  |  |
| 52 | 2.14.2 | Core Team Meeting 2 | 1h | 2010-09-20 08:00 A | 2010-09-20 09:00 A |  | 100% | start no earlier than 2010-09-20 08:00 |  |  |  |
| 53 | 2.14.3 | Core Team Meeting 3 | 1h | 2010-09-27 08:00 A | 2010-09-27 09:00 A |  | 100% | start no earlier than 2010-09-27 08:00 |  |  |  |
| 54 | 2.14.4 | Core Team Meeting 4 | 1h | 2010-10-04 08:00 A | 2010-10-04 09:00 A |  | 100% | start no earlier than 2010-10-04 08:00 |  |  |  |
| 55 | 2.14.5 | Core Team Meeting 5 | 1h | 2010-10-11 08:00 A | 2010-10-11 09:00 A |  | 100% | start no earlier than 2010-10-11 08:00 |  |  |  |
| 56 | 2.14.6 | Core Team Meeting 6 | 1h | 2010-10-18 08:00 A | 2010-10-18 09:00 A |  | 100% | start no earlier than 2010-10-18 08:00 |  |  |  |
| 57 | 2.14.7 | Core Team Meeting 7 | 1h | 2010-10-25 08:00 A | 2010-10-25 09:00 A |  | 100% | start no earlier than 2010-10-25 08:00 |  |  |  |
| 58 | 2.14.8 | Core Team Meeting 8 | 1h | 2010-11-01 08:00 A | 2010-11-01 09:00 A |  | 100% | start no earlier than 2010-11-01 08:00 |  |  |  |
| 59 | 2.14.9 | Core Team Meeting 9 | 1h | 2010-11-08 08:00 A | 2010-11-08 09:00 A |  | 100% | start no earlier than 2010-11-08 08:00 |  |  |  |
| 60 | 2.14.10 | Core Team Meeting 10 | 1h | 2010-11-15 08:00 A | 2010-11-15 09:00 A |  | 100% | start no earlier than 2010-11-15 08:00 |  |  |  |
| 61 | 2.14.11 | Core Team Meeting 11 | 1h | 2010-11-22 08:00 A | 2010-11-22 09:00 A |  | 100% | start no earlier than 2010-11-22 08:00 |  |  |  |
| 62 | 2.14.12 | Core Team Meeting 12 | 1h | 2010-11-29 08:00 A | 2010-11-29 09:00 A |  | 100% | start no earlier than 2010-11-29 08:00 |  |  |  |
| 63 | 2.14.13 | Core Team Meeting 13 | 1h | 2010-12-06 08:00 A | 2010-12-06 09:00 A |  | 100% | start no earlier than 2010-12-06 08:00 |  |  |  |
| 64 | 2.14.14 | Core Team Meeting 14 | 1h | 2010-12-13 08:00 A | 2010-12-13 09:00 A |  | 100% | start no earlier than 2010-12-13 08:00 |  |  |  |
| 65 | 2.14.15 | Core Team Meeting 15 | 1h | 2010-12-20 08:00 A | 2010-12-20 09:00 A |  | 100% | start no earlier than 2010-12-20 08:00 |  |  |  |

| ID | WBS | Task | Duration | Start | Finish | Predecessors | Complete | Constraint | Resources | Work | Actual work |
| --- | --- | --- | --- | --- | --- | --- | --- | --- | --- | --- | --- |
| 66 | 2.15 | **SAPbiz Meeting** | 90.25d | 2010-09-22 08:00 A | 2011-01-26 10:00 A |  | 100% |  |  |  |  |
| 67 | 2.15.1 | SAPbiz Meeting 1 | 2h | 2010-09-22 08:00 A | 2010-09-22 10:00 A |  | 100% | start no earlier than 2010-09-22 08:00 |  |  |  |
| 68 | 2.15.2 | SAPbiz Meeting 2 | 2h | 2010-10-27 08:00 A | 2010-10-27 10:00 A |  | 100% | start no earlier than 2010-10-27 08:00 |  |  |  |
| 69 | 2.15.3 | SAPbiz Meeting 3 | 2h | 2010-11-24 08:00 A | 2010-11-24 10:00 A |  | 100% | start no earlier than 2010-11-24 08:00 |  |  |  |
| 70 | 2.15.4 | SAPbiz Meeting 4 | 2h | 2010-12-22 08:00 A | 2010-12-22 10:00 A |  | 100% | start no earlier than 2010-12-22 08:00 |  |  |  |
| 71 | 2.15.5 | SAPbiz Meeting 5 | 2h | 2011-01-26 08:00 A | 2011-01-26 10:00 A |  | 100% | start no earlier than 2011-01-26 08:00 |  |  |  |
| 72 | 2.16 | **R3 Admin Meeting** | 105.12d | 2010-08-27 08:00 A | 2011-01-21 09:00 A |  | 100% |  |  |  |  |
| 73 | 2.16.1 | R3 Admin Meeting 1 | 1h | 2010-08-27 08:00 A | 2010-08-27 09:00 A |  | 100% | start no earlier than 2010-08-27 08:00 |  |  |  |
| 74 | 2.16.2 | R3 Admin Meeting 2 | 1h | 2010-09-03 08:00 A | 2010-09-03 09:00 A |  | 100% | start no earlier than 2010-09-03 08:00 |  |  |  |
| 75 | 2.16.3 | R3 Admin Meeting 3 | 1h | 2010-09-10 08:00 A | 2010-09-10 09:00 A |  | 100% | start no earlier than 2010-09-10 08:00 |  |  |  |
| 76 | 2.16.4 | R3 Admin Meeting 4 | 1h | 2010-09-17 08:00 A | 2010-09-17 09:00 A |  | 100% | start no earlier than 2010-09-17 08:00 |  |  |  |
| 77 | 2.16.5 | R3 Admin Meeting 5 | 1h | 2010-09-24 08:00 A | 2010-09-24 09:00 A |  | 100% | start no earlier than 2010-09-24 08:00 |  |  |  |
| 78 | 2.16.6 | R3 Admin Meeting 6 | 1h | 2010-10-01 08:00 A | 2010-10-01 09:00 A |  | 100% | start no earlier than 2010-10-01 08:00 |  |  |  |
| 79 | 2.16.7 | R3 Admin Meeting 7 | 1h | 2010-10-08 08:00 A | 2010-10-08 09:00 A |  | 100% | start no earlier than 2010-10-08 08:00 |  |  |  |
| 80 | 2.16.8 | R3 Admin Meeting 8 | 1h | 2010-10-15 08:00 A | 2010-10-15 09:00 A |  | 100% | start no earlier than 2010-10-15 08:00 |  |  |  |
| 81 | 2.16.9 | R3 Admin Meeting 9 | 1h | 2010-10-22 08:00 A | 2010-10-22 09:00 A |  | 100% | start no earlier than 2010-10-22 08:00 |  |  |  |
| 82 | 2.16.10 | R3 Admin Meeting 10 | 1h | 2010-10-29 08:00 A | 2010-10-29 09:00 A |  | 100% | start no earlier than 2010-10-29 08:00 |  |  |  |
| 83 | 2.16.11 | R3 Admin Meeting 11 | 1h | 2010-11-05 08:00 A | 2010-11-05 09:00 A |  | 100% | start no earlier than 2010-11-05 08:00 |  |  |  |
| 84 | 2.16.12 | R3 Admin Meeting 12 | 1h | 2010-11-12 08:00 A | 2010-11-12 09:00 A |  | 100% | start no earlier than 2010-11-12 08:00 |  |  |  |
| 85 | 2.16.13 | R3 Admin Meeting 13 | 1h | 2010-11-19 08:00 A | 2010-11-19 09:00 A |  | 100% | start no earlier than 2010-11-19 08:00 |  |  |  |
| 86 | 2.16.14 | R3 Admin Meeting 14 | 1h | 2010-11-26 08:00 A | 2010-11-26 09:00 A |  | 100% | start no earlier than 2010-11-26 08:00 |  |  |  |
| 87 | 2.16.15 | R3 Admin Meeting 15 | 1h | 2010-12-03 08:00 A | 2010-12-03 09:00 A |  | 100% | start no earlier than 2010-12-03 08:00 |  |  |  |
| 88 | 2.16.16 | R3 Admin Meeting 16 | 1h | 2010-12-10 08:00 A | 2010-12-10 09:00 A |  | 100% | start no earlier than 2010-12-10 08:00 |  |  |  |
| 89 | 2.16.17 | R3 Admin Meeting 17 | 1h | 2010-12-17 08:00 A | 2010-12-17 09:00 A |  | 100% | start no earlier than 2010-12-17 08:00 |  |  |  |
| 90 | 2.16.18 | R3 Admin Meeting 20 | 1h | 2011-01-07 08:00 A | 2011-01-07 09:00 A |  | 100% | start no earlier than 2011-01-07 08:00 |  |  |  |
| 91 | 2.16.19 | R3 Admin Meeting 21 | 1h | 2011-01-14 08:00 A | 2011-01-14 09:00 A |  | 100% | start no earlier than 2011-01-14 08:00 |  |  |  |
| 92 | 2.16.20 | R3 Admin Meeting 22 | 1h | 2011-01-21 08:00 A | 2011-01-21 09:00 A |  | 100% | start no earlier than 2011-01-21 08:00 |  |  |  |
| 93 | 2.17 | Communicate cut-over plan | 1h | 2010-11-24 16:00 A | 2010-11-24 17:00 A | 29 | 100% |  | Core | 1h | 1h |
| 94 | 2.18 | Schedule Lessons Learned meeting | 1h | 2011-01-20 08:00 A | 2011-01-20 09:00 A | 271FS+25d | 100% |  | PM | 1h | 1h |

| ID | WBS | Task | Duration | Start | Finish | Predecessors | Complete | Resources | Work | Actual work |
| --- | --- | --- | --- | --- | --- | --- | --- | --- | --- | --- |
| 95 | 3 | **Develop SAP SP Unit Test db** | 24.83d | 2010-08-23 08:00 A | 2010-09-24 15:40 A |  | 100% |  | 84h | 84h |
| 96 | 3.1 | Schedule meeting with developer team lead | 1h | 2010-09-09 10:40 A | 2010-09-09 11:40 A | 12 | 100% | PM | 1h | 1h |
| 97 | 3.2 | Define reuirements | 1d | 2010-08-23 08:00 A | 2010-08-23 17:00 A |  | 100% | PM | 8h | 8h |
| 98 | 3.3 | SAP SP Unit Test db meeting | 2h | 2010-09-13 11:40 A | 2010-09-13 14:40 A | 96FS+2d | 100% | PM | 2h | 2h |
| 99 | 3.4 | Assign developer | 1h | 2010-09-13 14:40 A | 2010-09-13 15:40 A | 98 | 100% | IDD | 1h | 1h |
| 100 | 3.5 | Develop SAP SP Unit db | 9d | 2010-09-13 15:40 A | 2010-09-24 15:40 A | 99 | 100% | IDD | 72h | 72h |
| 101 | 4 | **Test Planning** | 40.5d | 2010-09-03 09:00 A | 2010-10-29 14:00 A |  | 100% |  | 1541h | 1541h |
| 102 | 4.1 | Define, document, communicate test case management procedure - templates, process, … | 4d | 2010-09-03 09:00 A | 2010-09-09 09:00 A | 2 | 100% | QA | 32h | 32h |
| 103 | 4.2 | **Unit Test Planning (UT)** | 30.33d | 2010-09-03 09:00 A | 2010-10-15 11:40 A | 102 | 100% |  | 309h | 309h |
| 104 | 4.2.1 | Execute SAP Transaction/Program usage report | 10d | 2010-09-03 09:00 A | 2010-09-17 09:00 A | 2 | 100% | R3 | 80h | 80h |
| 105 | 4.2.2 | Mirge usage report into SAP SP Unit Test db | 4h | 2010-09-24 15:40 A | 2010-09-27 10:40 A | 95 | 100% | IDD | 4h | 4h |
| 106 | 4.2.3 | Determine transactions / reports to be tested | 13d | 2010-09-27 10:40 A | 2010-10-14 10:40 A | 105 | 100% | TestC - FI; TestC-HR | 208h | 208h |
| 107 | 4.2.4 | Update SAP SP Unit Test db | 1d | 2010-10-14 10:40 A | 2010-10-15 10:40 A | 106 | 100% | TestC - FI; TestC-HR | 16h | 16h |
| 108 | 4.2.5 | Publish Unit test plan | 1h | 2010-10-15 10:40 A | 2010-10-15 11:40 A | 107 | 100% | PM | 1h | 1h |
| 109 | 4.3 | **Update Quality Center (QC) test script catalogs** | 26d | 2010-09-09 09:00 A | 2010-10-15 09:00 A | 102 | 100% |  | 1200h | 1200h |
| 110 | 4.3.1 | Convert SIT/UAT cases into QC | 20d | 2010-09-09 09:00 A | 2010-10-07 09:00 A |  | 100% | QA | 160h | 160h |
| 111 | 4.3.2 | Review transaction / report log for new items | 5d | 2010-09-09 09:00 A | 2010-09-16 09:00 A |  | 100% | TestC - FI; TestC-HR | 80h | 80h |
| 112 | 4.3.3 | Update test script catalog with new transactions / reports | 5d | 2010-09-16 09:00 A | 2010-09-23 09:00 A | 111 | 100% | TestC - FI; TestC-HR | 80h | 80h |
| 113 | 4.3.4 | Review test script catalog for missing / old test scripts | 2d | 2010-09-23 09:00 A | 2010-09-27 09:00 A | 112 | 100% | TestC - FI; TestC-HR | 32h | 32h |
| 114 | 4.3.5 | Create new / update old test scripts | 25d | 2010-09-09 09:00 A | 2010-10-14 09:00 A | 102 | 100% | TestC - FI; TestC-HR | 400h | 400h |
| 115 | 4.3.6 | Convert test cases to new template | 25d | 2010-09-09 09:00 A | 2010-10-14 09:00 A | 102 | 100% | TestC - FI; TestC-HR | 400h | 400h |
| 116 | 4.3.7 | Financial Team confirms completeness of test script catalog | 1d | 2010-10-14 09:00 A | 2010-10-15 09:00 A | 115 | 100% | FIN-Team | 8h | 8h |
| 117 | 4.3.8 | Logistics Team confirms completeness of test script catalog | 1d | 2010-10-14 09:00 A | 2010-10-15 09:00 A | 115 | 100% | Log-Team | 8h | 8h |
| 118 | 4.3.9 | EHS Team confirms completeness of test script catalog | 1d | 2010-10-14 09:00 A | 2010-10-15 09:00 A | 115 | 100% | EHS-Team | 8h | 8h |
| 119 | 4.3.10 | HR-Payroll Team confirms completeness of test script catalog | 1d | 2010-10-14 09:00 A | 2010-10-15 09:00 A | 115 | 100% | HRP-Team | 8h | 8h |
| 120 | 4.3.11 | Provide QA w/ FI/LOG/EHS QC user list | 1d | 2010-10-14 09:00 A | 2010-10-15 09:00 A | 115 | 100% | TestC-FI | 8h | 8h |
| 121 | 4.3.12 | Provide QA w/ HRP QC user list | 1d | 2010-10-14 09:00 A | 2010-10-15 09:00 A | 115 | 100% | TestC-HR | 8h | 8h |

| ID | WBS | Task | Duration | Start | Finish | Predecessors | Complete | Resources | Work | Actual work |
| --- | --- | --- | --- | --- | --- | --- | --- | --- | --- | --- |
| 122 | 4.4 | **Systems Integration Test Planning (SIT)** | 36.5d | 2010-09-09 09:00 A | 2010-10-29 14:00 A | 109SS | 100% |  |  |  |
| 123 | 4.4.1 | Send UA test script calatlog to business owners | 4h | 2010-09-09 09:00 A | 2010-09-09 14:00 A |  | 100% |  |  |  |
| 124 | 4.4.2 | Function Test Leads meet with Functional Areas to review/plan testing (repetitive) | 30d | 2010-09-09 14:00 A | 2010-10-21 14:00 A | 123 | 100% |  |  |  |
| 125 | 4.4.3 | Define business scenarios/tests to be used in SIT (add to QC test lab) | 30d | 2010-09-09 14:00 A | 2010-10-21 14:00 A | 123 | 100% |  |  |  |
| 126 | 4.4.4 | Update business scenarios as required | 2d | 2010-10-21 14:00 A | 2010-10-25 14:00 A | 125 | 100% |  |  |  |
| 127 | 4.4.5 | QA review of test lab selections | 2d | 2010-10-25 14:00 A | 2010-10-27 14:00 A | 126 | 100% |  |  |  |
| 128 | 4.4.6 | **Functional Teams confirm test plan** | 1d | 2010-10-25 14:00 A | 2010-10-26 14:00 A | 126 | 100% |  |  |  |
| 129 | 4.4.6.1 | Financial Team confirms completeness of business scenarios | 1d | 2010-10-25 14:00 A | 2010-10-26 14:00 A | 126 | 100% |  |  |  |
| 130 | 4.4.6.2 | Logistics Team confirms completeness of business scenarios | 1d | 2010-10-25 14:00 A | 2010-10-26 14:00 A | 126 | 100% |  |  |  |
| 131 | 4.4.6.3 | EHS Team confirms completeness of business scenarios | 1d | 2010-10-25 14:00 A | 2010-10-26 14:00 A | 126 | 100% |  |  |  |
| 132 | 4.4.6.4 | HR-Payroll Team confirms completeness of business scenarios | 1d | 2010-10-25 14:00 A | 2010-10-26 14:00 A | 126 | 100% |  |  |  |
| 133 | 4.4.7 | QA confirms completeness of business scenarios | 1d | 2010-10-25 14:00 A | 2010-10-26 14:00 A | 126 | 100% |  |  |  |
| 134 | 4.4.8 | Publish SIT Test Schedule | 1d | 2010-10-26 14:00 A | 2010-10-27 14:00 A | 133 | 100% |  |  |  |
| 135 | 4.4.9 | **User Acceptance of SIT Planning** | 2d | 2010-10-27 14:00 A | 2010-10-29 14:00 A | 134 | 100% |  |  |  |
| 136 | 4.4.9.1 | Send UA test script catalog to business owners | 4h | 2010-10-27 14:00 A | 2010-10-28 09:00 A |  | 100% |  |  |  |
| 137 | 4.4.9.2 | Business analysts update test script catalogs | 4h | 2010-10-29 09:00 A | 2010-10-29 14:00 A | 136FS+1d | 100% |  |  |  |
| 138 | 5 | **System Admin Preparation** | 15.5d | 2010-09-15 10:40 A | 2010-10-06 15:40 A | 15FS+10d | 100% |  | 140h | 140h |
| 139 | 5.1 | Review and update action log from previous year | 1d | 2010-09-15 10:40 A | 2010-09-16 10:40 A |  | 100% | PM; R3; ABAP Lead | 24h | 24h |
| 140 | 5.2 | Download HRP SP OSS Note Lists (15-26) | 1d | 2010-09-15 10:40 A | 2010-09-16 10:40 A |  | 100% | PM; BA1 | 16h | 16h |
| 141 | 5.3 | Format SP OSS Note Lists into a single spreadsheet and post on wiki | 4h | 2010-09-16 10:40 A | 2010-09-16 15:40 A | 140 | 100% | BA1 | 4h | 4h |
| 142 | 5.4 | Solution Manager Update - SM1 sandbox (SPS Level 21 -> SPS Level 24) | 3d | 2010-09-15 10:40 A | 2010-09-20 10:40 A |  | 100% | R3-4 | 24h | 24h |
| 143 | 5.5 | Solution Manager Update - SM2 dev/test (SPS Level 21 -> SPS Level 24) | 3d | 2010-09-20 10:40 A | 2010-09-23 10:40 A | 142 | 100% | R3-4 | 24h | 24h |
| 144 | 5.6 | Solution Manager Update - PSM production (SPS Level 21 -> SPS Level 24) | 2d | 2010-09-23 10:40 A | 2010-09-27 10:40 A | 143 | 100% | R3-4 | 16h | 16h |
| 145 | 5.7 | Produce Side Effects Report | 2d | 2010-10-04 15:40 A | 2010-10-06 15:40 A | 141FS+12d | 100% | R3-1 | 16h | 16h |
| 146 | 5.8 | Download Enh Packs, SP Stacks, SPs | 2d | 2010-10-04 15:40 A | 2010-10-06 15:40 A | 145SS | 100% | R3-2 | 16h | 16h |

| ID | WBS | Task | Type | Duration | Start | Finish | Predecessors | Complete | Constraint | Calendar | Resources | Work | Actual work |
| --- | --- | --- | --- | --- | --- | --- | --- | --- | --- | --- | --- | --- | --- |
| 147 | 6 | **Practice update (SF7)** |  | 17.5d | 2010-09-20 10:40 A | 2010-10-13 15:40 A | 138SS+3d | 100% |  |  |  | 140h | 140h |
| 148 | 6.1 | Identify & Prepare practice system |  | 13d | 2010-09-20 10:40 A | 2010-10-07 10:40 A |  | 100% |  |  | R3-1 | 104h | 104h |
| 149 | 6.2 | Apply SAP kernel update |  | 4h | 2010-10-07 10:40 A | 2010-10-07 15:40 A | 148 | 100% |  |  | R3-1 | 4h | 4h |
| 150 | 6.3 | Upgrade Oracle db |  | 8h | 2010-10-07 15:40 A | 2010-10-08 15:40 A | 149 | 100% |  |  | R3-1 | 8h | 8h |
| 151 | 6.4 | Test Install Support Packs 15-26 (Stacks 7 + SP25 + SP26) |  | 3d | 2010-10-08 15:40 A | 2010-10-13 15:40 A | 150 | 100% |  |  | R3-1 | 24h | 24h |
| 152 | 7 | PS Snapshot for SF3 (10/04/2010) |  | 1d | 2010-10-04 08:00 A | 2010-10-04 17:00 A |  | 100% | must start on 2010-10-04 08:00 |  |  |  |  |
| 153 | 8 | **Cleanup pending transports (to be moved before freeze)** |  | 15d | 2010-10-07 13:40 A | 2010-10-28 13:40 A | 42FS+20d | 100% |  |  |  | 224h | 224h |
| 154 | 8.1 | Create transport list |  | 1d | 2010-10-07 13:40 A | 2010-10-08 13:40 A | 6 | 100% |  |  | TransC | 8h | 8h |
| 155 | 8.2 | Determine status and plan for each |  | 3d | 2010-10-07 13:40 A | 2010-10-12 13:40 A | 6 | 100% |  |  | TransC | 24h | 24h |
| 156 | 8.3 | Execute pending transport plan |  | 12d | 2010-10-12 13:40 A | 2010-10-28 13:40 A | 155 | 100% |  |  | R3; TransC | 192h | 192h |
| 157 | 9 | **Refresh Staging Environment (SF3)** |  | 7.62d | 2010-10-08 08:00 A | 2010-10-19 14:00 A |  | 100% |  |  |  | 55h | 55h |
| 158 | 9.1 | Notify SAP Support Teams of Pending SF3 Outage |  | 1h | 2010-10-08 08:00 A | 2010-10-08 09:00 A | 152FS+3d | 100% |  |  | R3-1 | 1h | 1h |
| 159 | 9.2 | SF3 out of service/SF8 becomes system for OSS staging environment | milestone | 0h | 2010-10-09 17:00 A | 2010-10-09 17:00 A | 152FS+15d | 100% |  | 24 Hours |  |  |  |
| 160 | 9.3 | Holiday (Columbus Day) | milestone | 0h | 2010-10-11 17:00 A | 2010-10-11 17:00 A |  | 100% | must finish on 2010-10-11 17:00 |  |  |  |  |
| 161 | 9.4 | Refresh with 10/04/2010 PS1 Snapshot |  | 4d | 2010-10-11 08:00 A | 2010-10-14 17:00 A | 159 | 100% |  |  | R3 | 32h | 32h |
| 162 | 9.5 | Import PS1/SF3 Transport Gap (10/5-10/15) |  | 4h | 2010-10-15 08:00 A | 2010-10-15 12:00 A | 161 | 100% |  |  | R3-1 | 4h | 4h |
| 163 | 9.6 | Execute R3 Action Log |  | 4h | 2010-10-15 13:00 A | 2010-10-15 17:00 A | 162 | 100% |  |  | R3 | 4h | 4h |
| 164 | 9.7 | Unlock Action Log participants |  | 1h | 2010-10-18 08:00 A | 2010-10-18 09:00 A | 163 | 100% |  |  | R3-2 | 1h | 1h |
| 165 | 9.8 | Execute Refresh Action Log |  | 4h | 2010-10-18 08:00 A | 2010-10-18 12:00 A | 164 | 100% |  |  | All | 4h | 4h |
| 166 | 9.9 | Scramble sensitive data <hold off scrambling - perform after py sim run post SF3 upgrade> | milestone | 0d | 2010-10-18 12:00 A | 2010-10-18 12:00 A | 165 | 100% |  |  |  |  |  |
| 167 | 9.10 | Execute pre-upgrade payroll simulation run (ZM) & store results (for comparison) |  | 1d | 2010-10-18 13:00 A | 2010-10-19 12:00 A | 166 | 100% |  |  | HRP | 8h | 8h |
| 168 | 9.11 | Lock Action Log participants |  | 1h | 2010-10-19 13:00 A | 2010-10-19 14:00 A | 167 | 100% |  |  | R3-2 | 1h | 1h |
| 169 | 10 | **Obtain Final Support Pack** |  | 2d | 2010-10-14 08:00 A | 2010-10-15 17:00 A |  | 100% |  |  |  | 16h | 16h |
| 170 | 10.1 | October support pack available from SAP | milestone | 1d | 2010-10-14 08:00 A | 2010-10-14 17:00 A |  | 100% | must start on 2010-10-14 08:00 |  | SAP | 8h | 8h |
| 171 | 10.2 | Download support pack & most current SAP kernel patch |  | 1d | 2010-10-15 08:00 A | 2010-10-15 17:00 A | 170 | 100% |  |  | R3 | 8h | 8h |
| 172 | 11 | PS1 Snapshot for Test Environment (SH3 - 10/18/2010) |  | 1d | 2010-10-18 08:00 A | 2010-10-18 17:00 A |  | 100% | must start on 2010-10-18 08:00 |  |  |  |  |

| ID | WBS | Task | Type | Duration | Start | Finish | Predecessors | Complete | Constraint | Calendar | Resources | Work | Actual work |
| --- | --- | --- | --- | --- | --- | --- | --- | --- | --- | --- | --- | --- | --- |
| 173 | 12 | **Update Pre-staging Environment (SFK)** |  | 4d | 2010-10-18 21:00 A | 2010-10-22 17:00 A | 169FS+1d | 100% |  |  |  | 20h | 20h |
| 174 | 12.1 | Apply SAP kernel update (114) |  | 4h | 2010-10-19 08:00 A | 2010-10-19 12:00 A |  | 100% |  | 24 Hours | R3-1 | 4h | 4h |
| 175 | 12.2 | Upgrade Oracle db | milestone | 0h | 2010-10-18 21:00 A | 2010-10-19 05:00 A | 174 | 100% |  | 24 Hours | R3-1 |  |  |
| 176 | 12.3 | Install Support packages ( SP Stacks 7 + SP 25-27) |  | 36h | 2010-10-19 05:00 A | 2010-10-20 17:00 A | 175 | 100% |  | 24 Hours |  |  |  |
| 177 | 12.4 | Update ancillary systems (Portal - SPS 7; PI-ADS - OSS Notes) |  | 1d | 2010-10-21 08:00 A | 2010-10-21 17:00 A | 176 | 100% |  |  | R3-3; R3-4 | 16h | 16h |
| 178 | 12.5 | Validate security infrastructure (SNC) |  | 2d | 2010-10-21 08:00 A | 2010-10-22 17:00 A | 176 | 100% |  |  |  |  |  |
| 179 | 12.6 | Validate SAPGui interactions |  | 2d | 2010-10-21 08:00 A | 2010-10-22 17:00 A | 176 | 100% |  |  |  |  |  |
| 180 | 12.7 | Validate basic SAP functions work |  | 2d | 2010-10-21 08:00 A | 2010-10-22 17:00 A | 176 | 100% |  |  |  |  |  |
| 181 | 12.8 | SFK updated | milestone | 0h | 2010-10-22 17:00 A | 2010-10-22 17:00 A |  | 100% | must finish on 2010-10-22 17:00 |  |  |  |  |
| 182 | 13 | **Update Staging Environment (SF3)** |  | 6d | 2010-10-25 08:00 A | 2010-11-01 17:00 A | 181 | 100% |  |  |  | 125h | 125h |
| 183 | 13.1 | Apply SAP kernel update (114) |  | 2h | 2010-10-25 08:00 A | 2010-10-25 10:00 A | 181 | 100% |  |  | R3-1 | 2h | 2h |
| 184 | 13.2 | Install Support packages (SP Stacks 7 + SP 25-27) |  | 22h | 2010-10-26 12:00 A | 2010-10-27 10:00 A | 183 | 100% |  | 24 Hours | R3-1 | 6h | 6h |
| 185 | 13.3 | Upgrade Oracle db |  | 8h | 2010-10-27 10:00 A | 2010-10-28 10:00 A | 184 | 100% |  | 24 Hours | R3-2 | 8h | 8h |
| 186 | 13.4 | Back up SF3 |  | 2h | 2010-10-28 10:00 A | 2010-10-28 12:00 A | 185 | 100% |  |  |  |  |  |
| 187 | 13.5 | Update BSI (TUBs 183-187) |  | 2h | 2010-10-26 12:00 A | 2010-10-26 14:00 A | 184SS | 100% |  | 24 Hours | R3-1 | 2h | 2h |
| 188 | 13.6 | Update ancillary systems (Portal - SPS 7; PI-ADS - OSS Notes) |  | 1d | 2010-10-27 10:00 A | 2010-10-28 10:00 A | 184 | 100% |  |  | R3-1 [300%] | 24h | 24h |
| 189 | 13.7 | Produce SPAU report, Apply OSS notes |  | 1d | 2010-10-27 10:00 A | 2010-10-28 10:00 A | 184 | 100% |  |  | R3-4 | 8h | 8h |
| 190 | 13.8 | Post Support pack action log |  | 4h | 2010-10-26 14:00 A | 2010-10-27 09:00 A | 187 | 100% |  |  | R3-3 | 4h | 4h |
| 191 | 13.9 | Validate - external interfaces ITS, jco, mitid, fax. |  | 6h | 2010-10-27 09:00 A | 2010-10-27 16:00 A | 190 | 100% |  |  | R3-3 | 6h | 6h |
| 192 | 13.10 | Unlock Developers involved in SPAU analysis |  | 1h | 2010-10-27 16:00 A | 2010-10-27 17:00 A | 191 | 100% |  |  | R3-2 | 1h | 1h |
| 193 | 13.11 | Check, decide, apply MIT mods or use enhancement framework |  | 2d | 2010-10-28 08:00 A | 2010-10-29 17:00 A | 191FS+1d | 100% |  | 24 Hours | ABAP | 16h | 16h |
| 194 | 13.12 | SAP developer functionality validation |  | 2d | 2010-10-28 08:00 A | 2010-10-29 17:00 A | 193SS | 100% |  |  | ABAP [200%] | 32h | 32h |
| 195 | 13.13 | Execute post-upgrade payroll simulation run (ZM) & compare results |  | 1d | 2010-11-01 08:00 A | 2010-11-01 17:00 A | 193 | 100% |  |  | HRP | 8h | 8h |
| 196 | 13.14 | Execute post-upgrade DW extracts (limited testing - key extracts) |  | 1d | 2010-11-01 08:00 A | 2010-11-01 17:00 A | 193 | 100% |  |  | DW | 8h | 8h |
| 197 | 13.15 | SF3 updated | milestone | 0h | 2010-11-01 17:00 A | 2010-11-01 17:00 A |  | 100% | must finish on 2010-11-01 17:00 |  |  |  |  |
| 198 | 14 | Development freeze begins (non-SP development is put on hold) | milestone | 0h | 2010-11-01 17:00 A | 2010-11-01 17:00 A | 182 | 100% |  |  |  |  |  |

Notes:
- 174: Allow for one hour installation time.
- 176: Allow for twekve hours.
- 177: R3 needs to review security notes related to PI/ADS components. / Application of SPS 6 to Portal in process (R3-4).
- 196: Cost element and profit center groups : ZWHCEHI / Payroll results: ZWHPAYROLL_RESULTS_NEW / Overhead: ZWHGETTE, ZWHOHSHT, ZWHOHRT, ZWHOHCRD, ZWHOHBAS, ZWHCTLGN

| ID | WBS | Task | Type | Duration | Start | Finish | Predecessors | Complete | Constraint | Calendar | Resources | Work | Actual work |
| --- | --- | --- | --- | --- | --- | --- | --- | --- | --- | --- | --- | --- | --- |
| 199 | 15 | **Update Development Environment (SF2)** |  | 2d | 2010-11-01 17:00 A | 2010-11-03 17:00 A | 198 | 100% |  |  |  | 67h | 67h |
| 200 | 15.1 | Apply SAP kernel update (114) |  | 4h | 2010-11-01 17:00 A | 2010-11-01 21:00 A |  | 100% |  | 24 Hours | R3-1 | 4h | 4h |
| 201 | 15.2 | Install Support packages (SP Stacks 7 + SP 25-27) |  | 12h | 2010-11-01 17:00 A | 2010-11-02 05:00 A |  | 100% |  | 24 Hours | R3-1 | 12h | 12h |
| 202 | 15.3 | Apply BSI Tax Factory Update |  | 2h | 2010-11-02 08:00 A | 2010-11-02 10:00 A | 201 | 100% |  | 24 Hours | R3-1 | 2h | 2h |
| 203 | 15.4 | Upgrade ERP Oracle db |  | 8h | 2010-11-02 05:00 A | 2010-11-02 13:00 A | 202 | 100% |  | 24 Hours | R3-4 | 8h | 8h |
| 204 | 15.5 | Back up database |  | 6h | 2010-11-02 13:00 A | 2010-11-03 10:00 A | 203 | 100% |  |  | SO | 6h | 6h |
| 205 | 15.6 | Import transports from SF3 |  | 2h | 2010-11-02 10:00 A | 2010-11-02 12:00 A |  | 100% |  | 24 Hours | R3-1 | 2h | 2h |
| 206 | 15.7 | **Upgrade Portal (JP3)** |  | 1d | 2010-11-02 13:00 A | 2010-11-03 12:00 A | 205 | 100% |  |  |  | 14h | 14h |
| 207 | 15.7.1 | Apply SPS 7 |  | 6h | 2010-11-02 13:00 A | 2010-11-03 10:00 A |  | 100% |  |  | R3-4 | 6h | 6h |
| 208 | 15.7.2 | Upgrade Portal Oracle db |  | 8h | 2010-11-02 13:00 A | 2010-11-03 12:00 A |  | 100% |  |  | R3-4 | 8h | 8h |
| 209 | 15.8 | **Upgrade PI/ADS System (J11)** |  | 1d | 2010-11-02 08:00 A | 2010-11-02 17:00 A |  | 100% |  |  |  | 15h | 15h |
| 210 | 15.8.1 | Upgrade kernel |  | 1h | 2010-11-02 08:00 A | 2010-11-02 09:00 A |  | 100% |  |  | R3-3 | 1h | 1h |
| 211 | 15.8.2 | Apply SPS 7 |  | 6h | 2010-11-02 08:00 A | 2010-11-02 15:00 A |  | 100% |  |  | R3-3 | 6h | 6h |
| 212 | 15.8.3 | Upgrade PI/ADS Oracle db (J01) |  | 8h | 2010-11-02 08:00 A | 2010-11-02 17:00 A |  | 100% |  |  | R3-3 | 8h | 8h |
| 213 | 15.9 | Execute action log (add updates if necessary) |  | 4h | 2010-11-02 13:00 A | 2010-11-02 17:00 A | 207 | 100% |  |  | R3-1 | 4h | 4h |
| 214 | 15.10 | SF2 updated | milestone | 0h | 2010-11-03 17:00 A | 2010-11-03 17:00 A |  | 100% | must finish on 2010-11-03 17:00 |  |  |  |  |
| 215 | 16 | **Zuttreq updates** |  | 0.12d | 2010-11-04 08:00 A | 2010-11-04 09:00 A | 199 | 100% |  |  |  | 2h | 2h |
| 216 | 16.1 | Change target system for transport layer |  | 1h | 2010-11-04 08:00 A | 2010-11-04 09:00 A |  | 100% |  |  | R3-1 | 1h | 1h |
| 217 | 16.2 | Change target system in Zuttreq |  | 1h | 2010-11-04 08:00 A | 2010-11-04 09:00 A |  | 100% |  |  | ABAP Lead | 1h | 1h |
| 218 | 17 | **Unit Test Execution (performed in SF2)** |  | 5d | 2010-11-04 08:00 A | 2010-11-10 17:00 A | 199 | 100% |  |  |  | 160h | 160h |
| 219 | 17.1 | **Functional Tests** |  | 5d | 2010-11-04 08:00 A | 2010-11-10 17:00 A |  | 100% |  |  |  | 160h | 160h |
| 220 | 17.1.1 | Financial Unit Tests, Issue identification and retest |  | 5d | 2010-11-04 08:00 A | 2010-11-10 17:00 A |  | 100% |  |  | FIN | 40h | 40h |
| 221 | 17.1.2 | Logistics Unit Tests, Issue identification and retest |  | 5d | 2010-11-04 08:00 A | 2010-11-10 17:00 A |  | 100% |  |  | log | 40h | 40h |
| 222 | 17.1.3 | EHS Unit Tests, Issue identification and retest |  | 5d | 2010-11-04 08:00 A | 2010-11-10 17:00 A |  | 100% |  |  | EHS | 40h | 40h |
| 223 | 17.1.4 | HR-Payroll Unit Tests, Issue identification and retest |  | 5d | 2010-11-04 08:00 A | 2010-11-10 17:00 A |  | 100% |  |  | HRP | 40h | 40h |
| 224 | 17.2 | All functional teams ok environment and move to SIT |  | 4h | 2010-11-10 13:00 A | 2010-11-10 17:00 A | 219FF | 100% |  |  |  |  |  |
| 225 | 17.3 | Unit test complete | milestone | 0h | 2010-11-10 17:00 A | 2010-11-10 17:00 A | 224 | 100% |  |  |  |  |  |

| ID | WBS | Task | Type | Duration | Start | Finish | Predecessors | Complete | Calendar | Resources | Work | Actual work |
| --- | --- | --- | --- | --- | --- | --- | --- | --- | --- | --- | --- | --- |
| 226 | 18 | **Refresh Test Environment (SH3)** |  | 7.25d | 2010-10-28 08:00 A | 2010-11-08 10:00 A | 193SS | 100% |  |  | 104h | 104h |
| 227 | 18.1 | Pre-update DW extracts (store for comparisons - from PS1) |  | 4h | 2010-10-28 08:00 A | 2010-10-28 12:00 A |  | 100% |  | DW | 4h | 4h |
| 228 | 18.2 | Confirm/Setup/update gateway components for new test system |  | 4h | 2010-10-28 08:00 A | 2010-10-28 12:00 A |  | 100% |  | IDD | 4h | 4h |
| 229 | 18.3 | Refresh with 10/18/2010 PS1 Snapshot |  | 30h | 2010-10-28 08:00 A | 2010-11-02 15:00 A |  | 100% | 24 Hours | OIS [320%] | 96h | 96h |
| 230 | 18.4 | Post Restore Activities |  | 2d | 2010-11-02 15:00 A | 2010-11-04 15:00 A | 229 | 100% |  |  |  |  |
| 231 | 18.5 | Import PS1/SH3 Transport Gap (10/19-11/5) |  | 4h | 2010-11-04 15:00 A | 2010-11-05 10:00 A | 230 | 100% |  |  |  |  |
| 232 | 18.6 | Execute R3 Action Log |  | 4h | 2010-11-05 10:00 A | 2010-11-05 15:00 A | 231 | 100% |  |  |  |  |
| 233 | 18.7 | Execute Refresh Action Log |  | 4h | 2010-11-05 15:00 A | 2010-11-08 10:00 A | 232 | 100% |  |  |  |  |
| 234 | 19 | **Update Test Environment (SH3)** |  | 4d | 2010-11-05 08:00 A | 2010-11-10 19:00 A | 199FS+1d | 100% |  |  | 67h | 67h |
| 235 | 19.1 | Apply SAP kernel update (114) |  | 2h | 2010-11-08 10:00 A | 2010-11-08 12:00 A | 233 | 100% | 24 Hours | R3-1 | 2h | 2h |
| 236 | 19.2 | Install Support packages (SP Stacks 7 + SP 25-27) |  | 12h | 2010-11-08 12:00 A | 2010-11-09 00:00 A | 235 | 100% | 24 Hours | R3-1 | 12h | 12h |
| 237 | 19.3 | Apply BSI Tax Factory Update |  | 2h | 2010-11-09 00:00 A | 2010-11-09 02:00 A | 236 | 100% | 24 Hours | R3-1 | 2h | 2h |
| 238 | 19.4 | Import transports from SF3 |  | 2h | 2010-11-09 02:00 A | 2010-11-09 04:00 A | 237 | 100% | 24 Hours | R3-1 | 2h | 2h |
| 239 | 19.5 | Upgrade Oracle db |  | 8h | 2010-11-09 04:00 A | 2010-11-09 12:00 A | 238 | 100% | 24 Hours | R3-4 | 8h | 8h |
| 240 | 19.6 | Back up database |  | 6h | 2010-11-09 13:00 A | 2010-11-10 10:00 A | 239 | 100% |  | SO | 6h | 6h |
| 241 | 19.7 | Execute post support pack action log (add updates if necessary) |  | 4h | 2010-11-10 10:00 A | 2010-11-10 15:00 A | 240 | 100% |  | R3 | 4h | 4h |
| 242 | 19.8 | Import transports from SF2 |  | 2h | 2010-11-10 17:00 A | 2010-11-10 19:00 A | 225 | 100% | 24 Hours | R3-1 | 2h | 2h |
| 243 | 19.9 | Import Production Transports from 11/9 |  | 2h | 2010-11-10 10:00 A | 2010-11-10 12:00 A | 240 | 100% |  |  |  |  |
| 244 | 19.10 | DW Schedule Extract Jobs |  | 1h | 2010-11-10 15:00 A | 2010-11-10 16:00 A | 241 | 100% |  |  |  |  |
| 245 | 19.11 | **Upgrade Portal (JP5)** |  | 1d | 2010-11-05 08:00 A | 2010-11-05 17:00 A |  | 100% |  |  | 14h | 14h |
| 246 | 19.11.1 | Apply SPS 7 |  | 6h | 2010-11-05 08:00 A | 2010-11-05 15:00 A |  | 100% |  | R3-4 | 6h | 6h |
| 247 | 19.11.2 | Upgrade Portal Oracle db |  | 8h | 2010-11-05 08:00 A | 2010-11-05 17:00 A |  | 100% |  | R3-4 | 8h | 8h |
| 248 | 19.12 | **Upgrade PI/ADS System** |  | 1d | 2010-11-05 08:00 A | 2010-11-05 17:00 A |  | 100% |  |  | 15h | 15h |
| 249 | 19.12.1 | Update kernel |  | 1h | 2010-11-05 08:00 A | 2010-11-05 09:00 A |  | 100% |  | R3-3 | 1h | 1h |
| 250 | 19.12.2 | Apply SPS 7 |  | 6h | 2010-11-05 08:00 A | 2010-11-05 15:00 A |  | 100% |  | R3-3 | 6h | 6h |
| 251 | 19.12.3 | Upgrade PI/ADS Oracle db |  | 8h | 2010-11-05 08:00 A | 2010-11-05 17:00 A |  | 100% |  | R3-3 | 8h | 8h |
| 252 | 20 | Production Transport Freeze Begins (last transports allowed into PS1) | milestone | 0d | 2010-11-10 19:00 A | 2010-11-10 19:00 A | 234 | 100% |  |  |  |  |

| ID | WBS | Task | Type | Duration | Start | Finish | Predecessors | Complete | Constraint | Calendar | Resources | Work | Actual work |
| --- | --- | --- | --- | --- | --- | --- | --- | --- | --- | --- | --- | --- | --- |
| 253 | 21 | **Execute System Integration Tests (SH3)** |  | 21.5d | 2010-11-11 08:00 A | 2010-12-10 12:00 A | 218 | 100% |  |  |  | 220h | 220h |
| 254 | 21.1 | Holiday (Veterans Day) | milestone | 0d | 2010-11-11 17:00 A | 2010-11-11 17:00 A | 252FS+1d | 100% |  |  |  |  |  |
| 255 | 21.2 | Execute Payroll comparison run |  | 5d | 2010-11-11 08:00 A | 2010-11-17 17:00 A |  | 100% |  |  | HRP | 40h | 40h |
| 256 | 21.3 | Execute data warehouse extracts |  | 1d | 2010-11-12 08:00 A | 2010-11-12 17:00 A | 255SS+1d | 100% |  |  | DW | 8h | 8h |
| 257 | 21.4 | Analyze data warehouse extracts comparison |  | 1d | 2010-11-15 08:00 A | 2010-11-15 17:00 A | 256 | 100% |  |  | DW | 8h | 8h |
| 258 | 21.5 | Analyze payroll comparison run |  | 3d | 2010-11-18 08:00 A | 2010-11-22 17:00 A | 255 | 100% |  |  | HRP | 24h | 24h |
| 259 | 21.6 | Financial Close (month of October) |  | 1d | 2010-11-18 08:00 A | 2010-11-18 17:00 A | 255 | 100% |  |  | FIN | 8h | 8h |
| 260 | 21.7 | Execute Automated Testing |  | 1d | 2010-11-18 08:00 A | 2010-11-18 17:00 A | 255 | 100% |  |  | QA-4 | 8h | 8h |
| 261 | 21.8 | Execute General SIT |  | 12d | 2010-11-19 08:00 A | 2010-12-06 17:00 A | 260 | 100% |  |  | All | 96h | 96h |
| 262 | 21.9 | Issue Retesting |  | 2d | 2010-12-07 08:00 A | 2010-12-08 17:00 A | 261 | 100% |  |  | All | 16h | 16h |
| 263 | 21.10 | Execute pre-update validation testing |  | 1d | 2010-12-08 08:00 A | 2010-12-08 17:00 A | 261FS+1d | 100% |  |  | Bus-Val | 8h | 8h |
| 264 | 21.11 | System Integration Test sign-off |  | 4h | 2010-12-09 08:00 A | 2010-12-09 12:00 A | 263 | 100% |  |  | All | 4h | 4h |
| 265 | 21.12 | SIT complete | milestone | 0h | 2010-12-09 12:00 A | 2010-12-09 12:00 A | 264 | 100% |  |  |  |  |  |
| 266 | 21.13 | Final preparation work |  | 1d | 2010-12-09 13:00 A | 2010-12-10 12:00 A | 265 | 100% |  |  |  |  |  |
| 267 | 22 | **Pre-cutover weekend activities** |  | 0.12d | 2010-12-02 13:00 A | 2010-12-02 14:00 A | 271SS-6d | 100% |  |  |  | 3h | 3h |
| 268 | 22.1 | System message put out on SAP GUI |  | 1h | 2010-12-02 13:00 A | 2010-12-02 14:00 A |  | 100% |  |  | R3-1 | 1h | 1h |
| 269 | 22.2 | System message put out on SAPWeb & ESS&insideMIT pages |  | 1h | 2010-12-02 13:00 A | 2010-12-02 14:00 A |  | 100% |  |  | IDD | 1h | 1h |
| 270 | 22.3 | Send outage headsup message to community |  | 1h | 2010-12-02 13:00 A | 2010-12-02 14:00 A |  | 100% |  |  | PM | 1h | 1h |
| 271 | 23 | **Cutover weekend & Controlled Start** |  | 3.5d | 2010-12-10 12:00 A | 2010-12-15 17:00 A |  | 100% |  |  |  | 4h | 4h |
| 272 | 23.1 | Update production (detailed weekend cutover plan in a separate document) | milestone | 2d | 2010-12-10 12:00 A | 2010-12-11 04:00 A | 253 | 100% |  | 24 Hours |  |  |  |
| 273 | 23.2 | Production validation |  | 1d | 2010-12-11 12:00 A | 2010-12-11 20:00 A | 272FS+1d | 100% |  | 24 Hours | Bus [50%] | 4h | 4h |
| 274 | 23.3 | Go/No Go approval |  | 1h | 2010-12-11 20:00 A | 2010-12-11 21:00 A | 273 | 100% |  | 24 Hours |  |  |  |
| 275 | 23.4 | Updated production available | milestone | 0h | 2010-12-11 21:00 A | 2010-12-11 21:00 A | 274 | 100% |  |  |  |  |  |
| 276 | 23.5 | First Production pay run execution |  | 2d | 2010-12-14 08:00 A | 2010-12-15 17:00 A | 275FS+1d | 100% |  |  |  |  |  |
| 277 | 24 | Freezes End (development & production) | milestone | 0h | 2010-12-15 17:00 A | 2010-12-15 17:00 A | 276 | 100% |  |  |  |  |  |
| 278 | 25 | First Calendar 2011 Payroll |  | 1d | 2010-12-22 08:00 A | 2010-12-22 17:00 A |  | 100% | must finish on 2010-12-22 17:00 |  |  |  |  |

| ID | WBS | Task | Duration | Start | Finish | Predecessors | Complete | Remaining | Total slack |
| --- | --- | --- | --- | --- | --- | --- | --- | --- | --- |
| 279 | 26 | **Post go-live activities** | 33.12d | 2010-12-16 08:00 A | 2011-02-01 09:00 |  | 98% | 0.79d | 0d |
| 280 | 26.1 | Install SAP GUI level 16 on EHS PCs (see RT # 1397279) | 2h | 2010-12-16 08:00 | 2010-12-16 10:00 | 277 |  |  | 32.88d |
| 281 | 26.2 | SH3 Status Change | 1h | 2010-12-16 08:00 A | 2010-12-16 09:00 A | 277 | 100% |  |  |
| 282 | 26.3 | SH1 Status Change | 1h | 2010-12-16 08:00 A | 2010-12-16 09:00 A | 277 | 100% |  |  |
| 283 | 26.4 | SF5 Status Change | 1h | 2010-12-16 08:00 A | 2010-12-16 09:00 A | 277 | 100% |  |  |
| 284 | 26.5 | Scramble SF3 | 4h | 2010-12-16 08:00 | 2010-12-16 12:00 | 277 |  |  | 32.62d |
| 285 | 26.6 | PS1 Snapshot for SF5/SF8/SH1 | 1h | 2010-12-30 08:00 A | 2010-12-30 09:00 A | 277FS+10d | 100% |  |  |
| 286 | 26.7 | SF5 System refresh & update | 10d | 2010-12-30 09:00 A | 2011-01-13 09:00 A | 285 | 100% |  |  |
| 287 | 26.8 | SH1 System refresh & update | 10d | 2011-01-13 09:00 A | 2011-01-27 09:00 A | 286 | 100% |  |  |
| 288 | 26.9 | Zuttreq updates | 1h | 2011-01-27 09:00 A | 2011-01-27 10:00 A | 287 | 100% |  |  |
| 289 | 26.10 | Change target system in Zuttreq | 1h | 2011-01-13 09:00 A | 2011-01-13 10:00 A | 286 | 100% |  |  |
| 290 | 26.11 | SF8 System Refresh & Update | 10d | 2011-01-18 09:00 A | 2011-02-01 09:00 A | 286FS+3d | 100% |  |  |
